# Tiburon upgrade

Schedule from MS Project, 2006-04-27 to 2006-06-20, costs in $.
MBARI

## Calendars

- Standard: Mon-Fri 08:00-12:00, 13:00-17:00; Sat-Sun off.

## Resources

| Resource | Rate |
| --- | --- |
| Mike |  |
| Dave |  |
| Dale |  |
| Jose |  |
| Board Fabrications | 500 |
| HD/16ch 232 focal boards | 5700 |
| Camera Upgrade | 2000 |
| Focal Breakout boxes | 1500 |
| Misc components | 1000 |
| Focal FMB upgrade | 4000 |
| Focal CWDM 100BT | 12837 |

## Schedule

| ID | WBS | Task | Duration | Start | Finish | Predecessors | Total slack | Free slack | Constraint | Resources | Work | Cost |
| --- | --- | --- | --- | --- | --- | --- | --- | --- | --- | --- | --- | --- |
| 1 | 1 | **Relocate subsea VME to control room** | 39d? | 2006-04-27 | 2006-06-20 |  | 0d |  |  |  | 300h | 26,837 |
| 2 | 1.1 | Block diagram completed of proposed VME relocation plan | 3d | 2006-05-01 | 2006-05-03 |  | 34d |  | start no earlier than 2006-05-01 | Mike | 24h |  |
| 3 | 1.2 | Upgrade 3 chip camera with Insite lens controller | 20d | 2006-05-24 | 2006-06-20 |  | 0d |  | start no earlier than 2006-05-24 | Camera Upgrade |  | 2,000 |
| 4 | 1.3 | Obtain quote and lead time for HD/16ch boards (focal) | 1d? | 2006-04-27 | 2006-04-27 |  | 8d | 4d |  | Dale | 8h |  |
| 5 | 1.4 | Order HD/16ch -232 boards (Focal) | 28d | 2006-05-04 | 2006-06-12 | 4 | 5d | 0d | start no earlier than 2006-05-04 | HD/16ch 232 focal boards |  | 5,700 |
| 6 | 1.5 | **Control room hardware mods and tasks** | 32d | 2006-04-28 | 2006-06-12 |  | 6d |  |  |  | 80h | 1,600 |
| 7 | 1.5.1 | Burn spare CPU with SIO-32 image | 3d | 2006-05-08 | 2006-05-10 |  | 28d | 0d | start no earlier than 2006-05-08 | Mike | 24h |  |
| 8 | 1.5.2 | Complete specifications for Focal topside breakout boxes for HD/16ch 232 boards | 2d | 2006-04-28 | 2006-05-01 |  | 6d | 0d | start no earlier than 2006-04-28 | Dale [50%] | 8h |  |
| 9 | 1.5.3 | Order Focal breakout boxes | 30d | 2006-05-02 | 2006-06-12 | 8 | 6d |  |  | Focal Breakout boxes |  | 1,500 |
| 10 | 1.5.4 | Drawing for VME SIO-32 to Focal breakout box serial cables | 1d | 2006-05-08 | 2006-05-08 |  | 26d | 0d | start no earlier than 2006-05-08 | Dale | 8h |  |
| 11 | 1.5.5 | Fabricate SIO-32/Focal cables | 5d | 2006-05-09 | 2006-05-15 | 10 | 26d |  |  | Jose; Misc components [10%] | 40h | 100 |
| 12 | 1.6 | **Subsea hardware mods and tasks** | 34d | 2006-04-27 | 2006-06-13 |  | 5d |  |  |  | 140h | 17,537 |
| 13 | 1.6.1 | Pull Motion Pack CPU from Subsea VME | 0.25d | 2006-05-04 | 2006-05-04 |  | 33.5d | 0d | start no earlier than 2006-05-04 | Dave | 2h |  |
| 14 | 1.6.2 | Pull FIDI board from subsea VME | 0.25d | 2006-05-04 | 2006-05-04 | 13 | 33.5d |  | start no earlier than 2006-05-04 | Dave | 2h |  |
| 15 | 1.6.3 | Install new Focal FMB's | 0.5d | 2006-06-13 | 2006-06-13 | 5 | 5d | 0d |  | Focal FMB upgrade; Dale | 4h | 4,000 |
| 16 | 1.6.4 | Hook up new Focal CWDM ethernet port into system | 0.5d | 2006-06-13 | 2006-06-13 | 15 | 5d |  | start no earlier than 2006-05-30 | Dale; Focal CWDM 100BT | 4h | 12,837 |
| 17 | 1.6.5 | Design 232 to 485 circuit and pass over to Jose for board layout | 2d | 2006-04-27 | 2006-04-28 |  | 22d | 0d |  | Dave | 16h |  |
| 18 | 1.6.6 | Design 232 to 485 board | 5d | 2006-05-01 | 2006-05-05 | 17 | 24d | 0d |  | Jose | 40h |  |
| 19 | 1.6.7 | Fabricate 232 to 485 board | 5d | 2006-05-08 | 2006-05-12 | 18 | 24d | 0d |  | Board Fabrications |  | 500 |
| 20 | 1.6.8 | Build PCB's (Solder) | 3d | 2006-05-15 | 2006-05-17 | 19 | 24d |  |  | Jose; Misc components [10%] | 24h | 100 |
| 21 | 1.6.9 | Drawing for test jumper serial cables (232 to 485 board to existing vehicle cables | 1d | 2006-05-09 | 2006-05-09 |  | 25d | 0d | start no earlier than 2006-05-09 | Dale | 8h |  |
| 22 | 1.6.10 | Fabricate jumper cables | 5d | 2006-05-10 | 2006-05-16 | 21 | 25d |  |  | Jose; Misc components [10%] | 40h | 100 |
| 23 | 1.7 | **Testing** | 33d | 2006-04-27 | 2006-06-12 |  | 6d |  |  |  | 48h |  |
| 24 | 1.7.1 | **Test X.Andy through B&B 232-485 converters (Thruster and Pan & Tilt)** | 5d | 2006-04-27 | 2006-05-03 |  | 34d |  |  |  | 16h |  |
| 25 | 1.7.1.1 | Fabricate test cable for B&B test | 1d | 2006-04-27 | 2006-04-27 |  | 37d | 3d |  | Dave | 8h |  |
| 26 | 1.7.1.2 | B&B vehicle testing | 1d | 2006-05-03 | 2006-05-03 | 25 | 34d |  | start no earlier than 2006-05-03 | Dave | 8h |  |
| 27 | 1.7.2 | Bench test of new VME crate, 232 to 485 board and DCON | 1d | 2006-05-11 | 2006-05-11 | 7 | 28d |  |  | Mike | 8h |  |
| 28 | 1.7.3 | On board vehicle test | 1d | 2006-06-12 | 2006-06-12 |  | 6d |  | start no earlier than 2006-06-12 | Mike; Dale; Dave | 24h |  |
